# DT3GanttChartFinal

Schedule from MS Project, 2012-01-18 to 2012-04-27, A marks actual dates.
Michigan State University College of Engineering

## Calendars

- Standard: Mon-Fri 08:00-12:00, 13:00-17:00; Sat-Sun off. Exceptions (off unless hours are given): 2012-04-21 08:00-12:00, 13:00-17:00.

## Resources

| Resource |
| --- |
| Yan |
| Jeremy |
| Austin |
| Ryan |
| Chris |

## Schedule

| ID | WBS | Task | Type | Duration | Start | Finish | Predecessors | Complete | Remaining | Total slack | Free slack | Constraint | Resources | Work | Actual work |
| --- | --- | --- | --- | --- | --- | --- | --- | --- | --- | --- | --- | --- | --- | --- | --- |
| 1 | 1 | **Obtain all design specs** |  | 8d | 2012-01-18 A | 2012-01-27 A |  | 100% |  |  |  |  | Austin; Chris; Jeremy; Ryan; Yan | 320h | 320h |
| 2 | 1.1 | Talk with Dr. LeMaster | manual | 1d | 2012-01-23 A | 2012-01-23 A |  | 100% |  |  |  |  |  |  |  |
| 3 | 1.2 | Talk with Dr. Oweiss | manual | 1d | 2012-01-27 A | 2012-01-27 A |  | 100% |  |  |  |  |  |  |  |
| 4 | 2 | **Project Deliverables** |  | 62d | 2012-02-01 A | 2012-04-25 | 1 | 1% | 61.14d | 2d |  |  | Austin; Chris; Jeremy; Ryan; Yan | 2480h | 40h |
| 5 | 2.1 | Write pre-proposal | manual | 3d | 2012-02-01 A | 2012-02-03 | 3 | 33% | 2d |  |  | start no earlier than 2012-02-01 |  |  |  |
| 6 | 2.2 | Discuss proposal with Dr. LeMaster | manual | 1d | 2012-02-06 A | 2012-02-06 A | 5 | 100% |  |  |  |  |  |  |  |
| 7 | 2.3 | Proposal Presentation | manual | 1d | 2012-02-10 A | 2012-02-10 A | 5 | 100% |  |  |  |  |  |  |  |
| 8 | 2.4 | Discuss proposal with Dr. Oweiss | manual | 1d | 2012-02-17 | 2012-02-17 | 5 |  |  |  |  |  |  |  |  |
| 9 | 2.5 | Write Final Proposal |  | 5d | 2012-02-20 | 2012-02-24 | 5, 8 |  |  | 2d | 0d | finish no earlier than 2012-02-24 |  |  |  |
| 10 | 2.6 | Design Day Program Page | manual | 13d | 2012-02-15 | 2012-03-02 |  |  |  |  |  |  |  |  |  |
| 11 | 2.7 | Progress Report 1 | manual | 5d | 2012-02-27 | 2012-03-02 | 9 |  |  |  |  |  |  |  |  |
| 12 | 2.8 | Application Notes | manual | 20d | 2012-03-05 | 2012-03-30 | 11 |  |  |  |  |  |  |  |  |
| 13 | 2.9 | Technical Lecture | manual | 6d | 2012-03-28 | 2012-04-04 |  |  |  |  |  |  |  |  |  |
| 14 | 2.10 | Design Issues Paper | manual | 30d | 2012-03-05 | 2012-04-13 | 11 |  |  |  |  |  |  |  |  |
| 15 | 2.11 | Progress Report 2 | manual | 30d | 2012-03-05 | 2012-04-13 | 11 |  |  |  |  |  |  |  |  |
| 16 | 2.12 | Project Demonstration |  | 30d | 2012-03-05 | 2012-04-13 | 23 |  |  | 10d |  |  |  |  |  |
| 17 | 2.13 | Professional Self-assessment Papers | manual | 5d | 2012-04-13 | 2012-04-19 |  |  |  |  |  |  |  |  |  |
| 18 | 2.14 | Final Report | manual | 8d | 2012-04-16 | 2012-04-25 | 15 |  |  |  |  |  |  |  |  |
| 19 | 2.15 | Webpage | manual | 58d | 2012-02-06 | 2012-04-25 | 5 |  |  |  |  |  |  |  |  |
| 20 | 3 | **Project Construction** |  | 65d | 2012-01-30 A | 2012-04-26 | 2 | 4% | 62.19d | 0d |  |  |  | 3401.6h | 137.86h |
| 21 | 3.1 | Finish Mount Design |  | 10d | 2012-01-30 | 2012-02-10 | 2 |  |  | 6d | 0d | finish no earlier than 2012-02-10 | Yan | 80h |  |
| 22 | 3.2 | Order Parts for Mount |  | 5d | 2012-02-06 | 2012-02-10 | 5 |  |  | 11d | 1d |  | Yan | 40h |  |
| 23 | 3.3 | Construct Camera Mount |  | 14d | 2012-02-14 | 2012-03-02 | 22, 21 |  |  | 10d | 0d | start no earlier than 2012-02-14 | Yan; Jeremy | 224h |  |
| 24 | 3.4 | Research possible circuitry for phone-to-motor control |  | 10d | 2012-01-30 | 2012-02-10 | 2 |  |  | 6d | 0d | finish no earlier than 2012-02-10 | Austin; Ryan | 160h |  |
| 25 | 3.5 | Design Phone-to-motor interface circuitry |  | 25d | 2012-02-13 A | 2012-03-16 | 21, 24 | 24% | 19d | 0d |  |  | Austin; Ryan | 400h | 96h |
| 26 | 3.6 | Test Motor Control Circuitry |  | 15d | 2012-03-19 | 2012-04-06 | 25, 23 |  |  | 0d |  | start no earlier than 2012-03-19 | Austin; Ryan; Yan | 360h |  |
| 27 | 3.7 | Laptop control program | manual | 13d | 2012-03-21 | 2012-04-06 | 37 |  |  |  |  |  | Jeremy | 104h |  |
| 28 | 3.8 | Construct New Motor Control Circuitry | manual | 5d | 2012-04-09 | 2012-04-13 | 26, 34, 36 |  |  |  |  |  | Austin; Chris; Ryan; Yan | 160h |  |
| 29 | 3.9 | Integrate Mount and Circuitry | manual | 5d | 2012-04-16 | 2012-04-20 | 28 |  |  |  |  |  | Austin; Chris; Ryan | 120h |  |

| ID | WBS | Task | Type | Duration | Start | Finish | Predecessors | Complete | Remaining | Total slack | Free slack | Constraint | Resources | Work | Actual work |
| --- | --- | --- | --- | --- | --- | --- | --- | --- | --- | --- | --- | --- | --- | --- | --- |
| 30 | 3.10 | **Android development** |  | 55d | 2012-01-30 A | 2012-04-13 |  | 3% | 53.45d |  |  |  | Chris; Jeremy | 1553.6h | 41.86h |
| 31 | 3.10.1 | Obtain Final Android Phone | manual | 7d | 2012-02-10 | 2012-02-20 |  |  |  |  |  |  | Jeremy | 56h |  |
| 32 | 3.10.2 | Research Android SDK Capabilities |  | 5d | 2012-01-30 | 2012-02-03 | 2 |  |  | 5d | 0d | start no earlier than 2012-01-30 | Chris | 40h |  |
| 33 | 3.10.3 | Begin writing non-phone-specific Control App | manual | 11d | 2012-02-06 | 2012-02-20 | 32 |  |  |  |  |  | Chris | 88h |  |
| 34 | 3.10.4 | Write parts of Control App that require phone to test | manual | 19d | 2012-02-21 | 2012-03-16 | 31, 33 |  |  |  |  |  | Chris | 152h |  |
| 35 | 3.10.5 | Output signal from headphone jack |  | 5d | 2012-02-06 | 2012-02-10 | 32 |  |  | 25d |  |  | Chris | 40h |  |
| 36 | 3.10.6 | Output correct signal from phone for control circuitry |  | 5d | 2012-03-19 | 2012-03-23 | 25, 35 |  |  | 10d |  | start no earlier than 2012-03-19 | Chris | 57.6h |  |
| 37 | 3.10.7 | File Input and Scheduling |  | 21d | 2012-02-13 A | 2012-03-12 |  | 12% | 18.4d | 5d | 0d | finish no earlier than 2012-03-12 | Jeremy | 168h | 20.8h |
| 38 | 3.10.8 | USB Output to Laptop |  | 19d | 2012-03-13 | 2012-04-06 | 37 |  |  | 5d |  |  | Jeremy | 152h |  |
| 39 | 3.11 | Test Control App with Mount |  | 5d | 2012-04-21 | 2012-04-26 | 27, 29, 37, 38 |  |  | 0d |  | start no earlier than 2012-04-21 | Ryan; Austin; Yan; Jeremy; Chris | 200h |  |
| 40 | 4 | Design Day | manual | 1d | 2012-04-27 | 2012-04-27 | 20 |  |  |  |  |  | Austin; Chris; Jeremy; Ryan; Yan | 40h |  |
